# PROJEKTAVIMAS

Schedule from MS Project, 2025-01-01 to 2026-05-13.

## Calendars

- Standard: Mon-Fri 08:00-12:00, 13:00-17:00; Sat-Sun off. Exceptions (off unless hours are given): 2013-01-01 to 2030-01-01 (Naujieji metai, recurring), 2013-02-16 to 2030-02-16 (Valstybės atkurimo diena, recurring), 2013-03-11 to 2030-03-11 (Nepriklausomybes atkurimo diena, recurring), 2013-05-01 to 2030-05-01 (Tarptautine darbininku diena, recurring), 2013-06-24 to 2030-06-24 (Jonines (Rasos), recurring), 2013-07-06 to 2030-07-06 (Valstybes (Lietuvos karaliaus Mindaugo karunavimo) diena, recurring), 2013-08-15 to 2030-08-15 (Zoline, Sv. Mergeles Marijos dangun emimo svente, recurring), 2013-11-01 to 2030-11-01 (Visu sventuju diena, recurring), 2013-12-24 to 2030-12-24 (Sv. Kucios, recurring), 2013-12-25 to 2030-12-25 (Sv. Kaledos, recurring), 2013-12-26 to 2030-12-26 (Sv. Kaledos (antroji diena), recurring), 2019-06-21 to 2030-12-27 07:30-11:30, 12:15-15:15 (Darbo diena (V) 07:30-15:15, recurring), 2024-04-03 to 2029-01-15 07:30-11:30, 12:15-16:30 (Darbo diena (I-IV) 07:30-16:30, recurring), 2025-04-21 (Sv. Velykos (antroji diena)), 2026-04-06 (Sv. Velykos (antroji diena)).

## Resources

| Resource | Rate |
| --- | --- |
| Rangovas |  |
| Litgrid AB |  |
| Ekspertizės rangovas |  |
| Infostatyba |  |
| PV |  |
| ESO |  |
| _ITTAD ITTC TIG vyresnysis inžinierius | 17.8 |
| _ITTAD ITTC DPG PVS administratorius | 17.8 |
| _ITTAD ITTC VSG DVS administratorius | 17.8 |
| _ITTAD ITTC DPG duomenų tinklo administratorius (KR) | 17.8 |
| _ITTAD ITTC DPG duomenų tinklo administratorius (IP) | 17.8 |

## Schedule

| ID | WBS | Task | Type | Duration | Start | Finish | Predecessors | Baseline start | Baseline finish | Baseline duration | Total slack | Constraint | Resources | Work |
| --- | --- | --- | --- | --- | --- | --- | --- | --- | --- | --- | --- | --- | --- | --- |
| 1 | 1 | **Tiekėjo darbų atlikimo grafikas** |  | 64d | 2025-01-01 | 2025-04-03 |  |  |  |  | 0d |  |  |  |
| 2 | 1.1 | S3 - Pasirašyta sutartis | milestone | 0d | 2025-01-01 | 2025-01-01 |  |  |  |  | 0d |  |  |  |
| 3 | 1.2 | Prašymas pateikti reikalingą dokumentaciją/informaciją projektavimo darbams |  | 5d | 2025-01-02 | 2025-01-08 | 2 |  |  |  | 0d |  |  |  |
| 4 | 1.3 | Pateikta reikalinga dokumentacija/informacija projektavimo darbams |  | 15d | 2025-01-09 | 2025-01-29 | 3 |  |  |  | 0d |  |  |  |
| 5 | 1.4 | **Darbų atlikimo grafikas** |  | 44d | 2025-01-30 | 2025-04-03 |  |  |  |  | 0d |  |  |  |
| 6 | 1.4.1 | Parengti darbų atlikimo grafiką |  | 1d | 2025-01-30 | 2025-01-30 | 4 |  |  |  | 0d |  |  |  |
| 7 | 1.4.2 | Pateikti 1 peržiūrai darbų atlikimo grafiką |  | 21d | 2025-01-30 | 2025-03-03 | 6 |  |  |  | 0d |  |  |  |
| 8 | 1.4.3 | Pateikti pastabas po 1 peržiūros |  | 10d | 2025-03-03 | 2025-03-18 | 7 |  |  |  | 0d |  |  |  |
| 9 | 1.4.4 | Pateikti 2 peržiūrai darbų atlikimo grafiką |  | 7d | 2025-03-18 | 2025-03-27 | 8 |  |  |  | 0d |  |  |  |
| 10 | 1.4.5 | Pateikti pastabas po 2 peržiūros |  | 5d | 2025-03-27 | 2025-04-03 | 9 |  |  |  | 0d |  |  |  |
| 11 | 1.4.6 | Darbų atlikimo grafikas suderintas | milestone | 0d | 2025-04-03 | 2025-04-03 | 10 |  |  |  | 0d |  |  |  |
| 12 | 2 | **I ETAPAS** |  | 174d | 2025-04-03 | 2025-12-09 |  | 2019-12-18 | 2020-08-18 | 166d | 0d |  |  | 1040h |
| 13 | 2.1 | Projektuotojas pateikia galiojantį civilinės atsakomybės draudimo dokumentą | milestone | 0d | 2025-04-03 | 2025-04-03 | 11 |  |  |  | 0d | start no earlier than 2024-12-02 | Rangovas |  |
| 14 | 2.2 | Prašymas pateikti reikalingą dokumentaciją/informaciją techniniams darbams |  | 5d | 2025-04-03 | 2025-04-10 | 13 |  |  |  | 0d |  |  |  |
| 15 | 2.3 | Pateikta reikalinga dokumentacija/informacija techniniams darbams |  | 10d | 2025-04-10 | 2025-04-25 | 14 |  |  |  | 0d |  |  |  |
| 16 | 2.4 | Konsultacijos rengimo metu |  | 25d | 2025-04-25 | 2025-06-02 | 15 |  |  |  | 0d |  |  |  |
| 17 | 2.5 | Pateikti geologinių tyrinėjimų vietas susiderinimui |  | 5d | 2025-06-02 | 2025-06-09 | 16 |  |  |  | 0d | start no earlier than 2024-12-02 | Rangovas | 40h |
| 18 | 2.6 | Atlikti inžineriniai geodeziniai tyrinėjimai ir pateika įregistravimo pažyma |  | 20d | 2025-06-09 | 2025-07-08 | 17 | 2019-12-18 | 2020-01-14 | 16d | 0d |  | Rangovas | 160h |
| 19 | 2.7 | **Projektiniai pasiūlymai (PP)** |  | 75d | 2025-07-08 | 2025-10-22 |  | 2019-12-18 | 2020-07-10 | 139d | 0d |  |  | 600h |
| 20 | 2.7.1 | Projektinių pasiūlymų projekto rengimas |  | 30d | 2025-07-08 | 2025-08-20 | 18 | 2020-01-28 | 2020-02-26 | 22d | 0d | start no earlier than 2024-12-02 | Rangovas | 240h |
| 21 | 2.7.2 | Pakoreguoti ir pateikti projektinių pasiūlymų projektą 1 peržiūrai | milestone | 0d | 2025-08-20 | 2025-08-20 | 20 | 2020-02-26 | 2020-02-26 | 0d | 0d |  | Rangovas |  |
| 22 | 2.7.3 | Pateikti pastabas po 1 projektinių pasiūlymų projekto peržiūros |  | 10d | 2025-08-20 | 2025-09-03 | 21 | 2020-02-27 | 2020-03-17 | 13d | 0d |  | Litgrid AB | 80h |
| 23 | 2.7.4 | Pakoreguoti ir pateikti projektinių pasiūlymų projektą 2 peržiūrai |  | 10d | 2025-09-03 | 2025-09-17 | 22 | 2020-03-18 | 2020-04-03 | 13d | 0d |  | Rangovas | 80h |
| 24 | 2.7.5 | Pateikti pastabas po 2 projektinių pasiūlymų projekto peržiūros |  | 10d | 2025-09-17 | 2025-10-01 | 23 | 2020-04-06 | 2020-04-20 | 10d | 0d |  | Litgrid AB | 80h |
| 25 | 2.7.6 | Pakoreguoti ir pateikti projektinių pasiūlymų projektą 3 peržiūrai |  | 5d | 2025-10-01 | 2025-10-08 | 24 | 2020-04-21 | 2020-05-04 | 9d | 0d |  | Rangovas | 40h |
| 26 | 2.7.7 | Pateikti pastabas/suderinti po 3 projektinių pasiūlymų projekto |  | 10d | 2025-10-08 | 2025-10-22 | 25 | 2020-05-05 | 2020-05-18 | 10d | 0d |  | Litgrid AB | 80h |
| 27 | 2.7.8 | Projektiniai pasiūlymai suderinti | milestone | 0d | 2025-10-22 | 2025-10-22 | 26 |  |  |  | 0d |  | Litgrid AB |  |

| ID | WBS | Task | Type | Duration | Start | Finish | Predecessors | Baseline start | Baseline finish | Baseline duration | Total slack | Resources | Work |
| --- | --- | --- | --- | --- | --- | --- | --- | --- | --- | --- | --- | --- | --- |
| 28 | 2.8 | **Statybą leidžiantis dokumentas** |  | 34d | 2025-10-22 | 2025-12-09 |  | 2020-07-13 | 2020-08-18 | 27d | 0d |  | 240h |
| 29 | 2.8.1 | Komunikacija - Projektinių sprendinių pristatymas visuomenei |  | 3d | 2025-10-22 | 2025-10-27 | 27 | 2020-07-13 | 2020-07-13 | 1d | 0d | Rangovas | 24h |
| 30 | 2.8.2 | Projektiniai pasiūlymai pateikti į Infostatybą su visais reikiamais dokumentais |  | 1d | 2025-10-27 | 2025-10-28 | 29 | 2020-07-14 | 2020-07-16 | 3d | 0d | Infostatyba | 8h |
| 31 | 2.8.3 | Patikrinta pateiktos dokumentacijos sudėtis |  | 3d | 2025-10-28 | 2025-10-30 | 30 | 2020-07-17 | 2020-08-13 | 20d | 0d | Infostatyba | 24h |
| 32 | 2.8.4 | Suinteresuotos organizacijos patikrino pateiktą dokumentaciją |  | 20d | 2025-10-30 | 2025-11-27 | 31 | 2020-08-14 | 2020-08-18 | 3d | 0d | Infostatyba | 160h |
| 33 | 2.8.5 | Išduotas statybos leidimas |  | 3d | 2025-11-27 | 2025-12-03 | 32 | 2020-08-18 | 2020-08-18 | 0d | 0d | Rangovas | 24h |
| 34 | 2.8.6 | Komunikacija - SLD gavimas |  | 4d | 2025-12-03 | 2025-12-09 | 33 |  |  |  | 0d |  |  |
| 35 | 3 | **II ETAPAS** |  | 104d | 2025-12-09 | 2026-05-13 |  |  |  |  | 0d |  |  |
| 36 | 3.1 | **Techninis darbo projektas (TDP)** |  | 104d | 2025-12-09 | 2026-05-13 |  |  |  |  | 0d |  |  |
| 37 | 3.1.1 | Techninio darbo projekto rengimas |  | 30d | 2025-12-09 | 2026-01-26 | 34 |  |  |  | 0d |  |  |
| 38 | 3.1.2 | Pakoreguoti ir pateikti techninį darbo projektą 1 peržiūrai | milestone | 0d | 2026-01-26 | 2026-01-26 | 37 |  |  |  | 0d |  |  |
| 39 | 3.1.3 | Ekspertizės paslaugų pirkimo inicijavimas |  | 5d | 2026-01-26 | 2026-02-02 | 38 |  |  |  | 0d |  |  |
| 40 | 3.1.4 | Pateikti pastabas po 1 techninio darbo projekto peržiūros |  | 10d | 2026-02-02 | 2026-02-17 | 39 |  |  |  | 0d |  |  |
| 41 | 3.1.5 | Pakoreguoti ir pateikti techninį darbo projektą 2 peržiūrai |  | 10d | 2026-02-17 | 2026-03-03 | 40 |  |  |  | 0d |  |  |
| 42 | 3.1.6 | Pateikti pastabas po 2 techninio darbo projekto peržiūros |  | 10d | 2026-03-03 | 2026-03-18 | 41 |  |  |  | 0d |  |  |
| 43 | 3.1.7 | Pakoreguoti ir pateikti techninį darbo projektą 3 peržiūrai |  | 7d | 2026-03-18 | 2026-03-26 | 42 |  |  |  | 0d |  |  |
| 44 | 3.1.8 | Pateikti pastabas/suderinti po 3 techninio darbo projekto peržiūros |  | 10d | 2026-03-27 | 2026-04-13 | 43 |  |  |  | 0d |  |  |
| 45 | 3.1.9 | Pasirašyta Techninio darbo projekto ekspertizės paslaugų sutartis | milestone | 0d | 2026-04-13 | 2026-04-13 | 44 |  |  |  | 0d |  |  |
| 46 | 3.1.10 | Techninis darbo projektas suderintas | milestone | 0d | 2026-04-13 | 2026-04-13 | 45 |  |  |  | 0d |  |  |
| 47 | 3.1.11 | **Techninio darbo projekto bendroji ekspertizė** |  | 22d | 2026-04-13 | 2026-05-13 |  |  |  |  | 0d |  |  |
| 48 | 3.1.11.1 | Techninio darbo projekto bendroji ekspertizė |  | 20d | 2026-04-13 | 2026-05-11 | 46 |  |  |  | 0d |  |  |
| 49 | 3.1.11.2 | Pateikta ekspertizės teigiama išvada projektui |  | 1d | 2026-05-12 | 2026-05-12 | 48 |  |  |  | 0d |  |  |
| 50 | 3.1.11.3 | Pateiktas nurodymas apie techninio darbo projekto bendrųjų statinio rodiklių patvirtinimą |  | 1d | 2026-05-12 | 2026-05-13 | 49 |  |  |  | 0d |  |  |
| 51 | 3.1.11.4 | Techninis darbo projektas patvirtintas | milestone | 0d | 2026-05-13 | 2026-05-13 | 50 |  |  |  | 0d |  |  |
